# Employee Handbook Sample

Schedule from MS Project, 2009-03-09 to 2009-04-27.
sales@bestitdocuments.com

## Calendars

- Standard: Mon-Fri 08:00-12:00, 13:00-17:00; Sat-Sun off.

## Resources

| Resource | Group | Rate |
| --- | --- | --- |
| Designer | Contractor |  |
| Sr Editor | Editor | 75 |
| Contributor | Editor | 25 |
| Sr Writer | Writer | 75 |
| Stakeholder |  | 25 |

## Schedule

| ID | WBS | Task | Type | Duration | Start | Finish | Predecessors | Total slack | Free slack |
| --- | --- | --- | --- | --- | --- | --- | --- | --- | --- |
| 1 | 1 | Design Manual's Format |  | 1w | 2009-03-09 | 2009-03-13 |  | 0d |  |
| 2 | 2 | **Writing Phase** |  | 19d | 2009-03-16 | 2009-04-09 | 1 | 0d |  |
| 3 | 2.1 | Introduction |  | 1d | 2009-03-16 | 2009-03-16 |  | 5d | 0d |
| 4 | 2.2 | Chapter 1 |  | 5d | 2009-03-17 | 2009-03-23 | 3 | 5d | 0d |
| 5 | 2.3 | Chapter 2 |  | 4d | 2009-03-16 | 2009-03-19 |  | 0d |  |
| 6 | 2.4 | Chapter 3 |  | 7d | 2009-03-20 | 2009-03-30 | 5 | 0d |  |
| 7 | 2.5 | Chapter 4 |  | 3d | 2009-03-31 | 2009-04-02 | 6 | 0d |  |
| 8 | 2.6 | Chapter 5 |  | 5d | 2009-04-03 | 2009-04-09 | 7 | 0d |  |
| 9 | 3 | **Editing Phase** |  | 20d | 2009-03-17 | 2009-04-13 | 2SS | 0d |  |
| 10 | 3.1 | Edit Introduction |  | 2d | 2009-03-17 | 2009-03-18 | 3 | 8d | 3d |
| 11 | 3.2 | Edit Chapter 1 |  | 2d | 2009-03-24 | 2009-03-25 | 10, 4 | 5d | 0d |
| 12 | 3.3 | Edit Chapter 2 |  | 2d | 2009-03-26 | 2009-03-27 | 11, 5 | 5d | 1d |
| 13 | 3.4 | Edit Chapter 3 |  | 2d | 2009-03-31 | 2009-04-01 | 12, 6 | 4d | 1d |
| 14 | 3.5 | Edit Chapter 4 |  | 2d | 2009-04-03 | 2009-04-06 | 13, 7 | 3d |  |
| 15 | 3.6 | Edit Chapter 5 |  | 2d | 2009-04-10 | 2009-04-13 | 14, 8 | 0d |  |
| 16 | 4 | **Final Touches** |  | 9.38d | 2009-04-14 | 2009-04-27 | 9 | 0d |  |
| 17 | 4.1 | Final Chapter Corrections |  | 3d | 2009-04-14 | 2009-04-16 |  | 0d |  |
| 18 | 4.2 | Glossary |  | 3d | 2009-04-17 | 2009-04-21 | 17 | 0d |  |
| 19 | 4.3 | Table of Contents |  | 3h | 2009-04-22 | 2009-04-22 | 18 | 0d |  |
| 20 | 4.4 | Index |  | 3d | 2009-04-22 | 2009-04-27 | 19 | 0d |  |
| 21 | 5 | End Manual | milestone | 0d | 2009-04-27 | 2009-04-27 | 16 | 0d |  |
