# ex_hsdic_msp

Schedule from MS Project, 2013-11-25 to 2013-12-24, scheduled back from the finish.
www.bestitdocuments.com

## Calendars

- Standard: Mon-Fri 08:00-12:00, 13:00-17:00; Sat-Sun off.

## Resources

| Resource |
| --- |
| Architect1 |
| Consultant1 |
| Project Manager1 |

## Schedule

| ID | WBS | Task | Duration | Start | Finish | Predecessors | Total slack | Free slack | Constraint | Resources | Work |
| --- | --- | --- | --- | --- | --- | --- | --- | --- | --- | --- | --- |
| 1 | HSDIC.IMP | **Integration Set Up** | 21.06d? | 2013-11-25 16:30 | 2013-12-24 17:00 |  | 0d |  | as late as possible |  | 197.5h |
| 2 | HSDIC.IMP.01 | **Technical Startup** | 4.31d? | 2013-11-25 16:30 | 2013-12-02 10:00 |  | 0d |  | as late as possible |  | 39.5h |
| 3 | HSDIC.IMP.01.010 | Perform Engagement Management Setup Activities | 4.31d? | 2013-11-25 16:30 | 2013-12-02 10:00 |  | 0d |  |  | Project Manager1 | 34.5h |
| 4 | HSDIC.IMP.01.020 | Prepare for Engagement | 0.12d? | 2013-11-25 16:30 | 2013-11-26 08:30 |  | 3.69d | 0d |  | Consultant1 | 1h |
| 5 | HSDIC.IMP.01.030 | Review Implementation Information with Client | 0.25d? | 2013-11-26 08:30 | 2013-11-26 10:30 | 4 | 3.69d | 0d |  | Consultant1 | 2h |
| 6 | HSDIC.IMP.01.040 | Review Project Schedule with Client | 0.25d? | 2013-11-26 10:30 | 2013-11-26 13:30 | 5 | 3.69d |  |  | Consultant1 | 2h |
| 7 | HSDIC.IMP.02 | **Architecture and Design** | 3.38d? | 2013-12-02 10:00 | 2013-12-05 14:00 |  | 0d |  | as late as possible |  | 51h |
| 8 | HSDIC.IMP.02.010 | Conduct Briefing with Client Project Sponsor | 0.25d? | 2013-12-02 10:00 | 2013-12-02 12:00 | 6, 2 | 0d |  |  | Consultant1 | 2h |
| 9 | HSDIC.IMP.02.020 | Conduct Kick-Off Session | 0.12d? | 2013-12-02 13:00 | 2013-12-02 14:00 | 8 | 0d |  |  | Consultant1 | 1h |
| 10 | HSDIC.IMP.02.030 | Gather Harvest Information | 0.12d? | 2013-12-02 14:00 | 2013-12-02 15:00 | 9 | 0d |  |  | Architect1; Consultant1 | 2h |
| 11 | HSDIC.IMP.02.040 | Gather Service Desk Information | 0.12d? | 2013-12-02 15:00 | 2013-12-02 16:00 | 10 | 0d |  |  | Architect1; Consultant1 | 2h |
| 12 | HSDIC.IMP.02.050 | Gather Clarity Information | 0.12d? | 2013-12-02 16:00 | 2013-12-02 17:00 | 11 | 0d |  |  | Architect1; Consultant1 | 2h |
| 13 | HSDIC.IMP.02.060 | Gather Users and Role Information | 0.12d? | 2013-12-03 08:00 | 2013-12-03 09:00 | 12 | 0d |  |  | Architect1; Consultant1 | 2h |
| 14 | HSDIC.IMP.02.070 | Gather Service Desk to Harvest Integration Information | 0.5d? | 2013-12-03 09:00 | 2013-12-03 14:00 | 13 | 0d |  |  | Architect1; Consultant1 | 8h |
| 15 | HSDIC.IMP.02.080 | Gather Service Desk to Clarity Integration Information | 0.5d? | 2013-12-03 14:00 | 2013-12-04 09:00 | 14 | 0d |  |  | Architect1; Consultant1 | 8h |
| 16 | HSDIC.IMP.02.090 | Gather Harvest to Clarity Integration Information | 0.25d? | 2013-12-04 09:00 | 2013-12-04 11:00 | 15 | 0d |  |  | Architect1; Consultant1 | 4h |
| 17 | HSDIC.IMP.02.100 | Create Solution Architecture Specification | 1d? | 2013-12-04 11:00 | 2013-12-05 11:00 | 16 | 0d |  |  | Architect1; Consultant1 | 16h |
| 18 | HSDIC.IMP.02.110 | Review Solution Architecture Specification with Client | 0.25d? | 2013-12-05 11:00 | 2013-12-05 14:00 | 17 | 0d |  |  | Architect1; Consultant1 | 4h |
| 19 | HSDIC.IMP.03 | **Service Desk Configuration** | 3.94d? | 2013-12-05 14:00 | 2013-12-11 13:30 |  | 0d |  | as late as possible |  | 31.5h |
| 20 | HSDIC.IMP.03.010 | Install Integration Files | 0.12d? | 2013-12-05 14:00 | 2013-12-05 15:00 | 18 | 0d |  |  | Consultant1 | 1h |
| 21 | HSDIC.IMP.03.020 | Configure the Integration Workflow in Service Desk | 0.31d? | 2013-12-05 15:00 | 2013-12-06 08:30 | 20 | 0d |  |  | Consultant1 | 2.5h |
| 22 | HSDIC.IMP.03.030 | Configure the Service Desk Forms | 1d? | 2013-12-06 08:30 | 2013-12-09 08:30 | 21 | 0d |  |  | Consultant1 | 8h |
| 23 | HSDIC.IMP.03.040 | Create Integration Tables and Populate with Data | 0.5d? | 2013-12-09 08:30 | 2013-12-09 13:30 | 22 | 0d |  |  | Consultant1 | 4h |
| 24 | HSDIC.IMP.03.050 | Provision User IDs | 0.25d? | 2013-12-09 13:30 | 2013-12-09 15:30 | 23 | 0d |  |  | Consultant1 | 2h |
| 25 | HSDIC.IMP.03.060 | Configure Parameter File for Harvest Integration | 1.25d? | 2013-12-09 15:30 | 2013-12-11 08:30 | 24 | 0d |  |  | Consultant1 | 10h |
| 26 | HSDIC.IMP.03.070 | Configure Parameter File for Clarity Integration | 0.25d? | 2013-12-11 08:30 | 2013-12-11 10:30 | 25 | 0d |  |  | Consultant1 | 2h |
| 27 | HSDIC.IMP.03.080 | Test Service Desk Configuration | 0.25d? | 2013-12-11 10:30 | 2013-12-11 13:30 | 26 | 0d |  |  | Consultant1 | 2h |

| ID | WBS | Task | Duration | Start | Finish | Predecessors | Total slack | Constraint | Resources | Work |
| --- | --- | --- | --- | --- | --- | --- | --- | --- | --- | --- |
| 28 | HSDIC.IMP.04 | **Harvest Configuration** | 2.44d? | 2013-12-11 13:30 | 2013-12-13 17:00 |  | 0d | as late as possible |  | 19.5h |
| 29 | HSDIC.IMP.04.010 | Install Integration Files | 0.25d? | 2013-12-11 13:30 | 2013-12-11 15:30 | 27 | 0d |  | Consultant1 | 2h |
| 30 | HSDIC.IMP.04.020 | Configure the Integration Lifecycle in Harvest | 0.31d? | 2013-12-11 15:30 | 2013-12-12 09:00 | 29 | 0d |  | Consultant1 | 2.5h |
| 31 | HSDIC.IMP.04.030 | Provision User IDs | 0.25d? | 2013-12-12 09:00 | 2013-12-12 11:00 | 30 | 0d |  | Consultant1 | 2h |
| 32 | HSDIC.IMP.04.040 | Create the Harvest Integration Forms | 0.5d? | 2013-12-12 11:00 | 2013-12-12 16:00 | 31 | 0d |  | Consultant1 | 4h |
| 33 | HSDIC.IMP.04.050 | Configure Parameter File for Service Desk Integration | 0.25d? | 2013-12-12 16:00 | 2013-12-13 09:00 | 32 | 0d |  | Consultant1 | 2h |
| 34 | HSDIC.IMP.04.060 | Configure Parameter File for Clarity Integration | 0.25d? | 2013-12-13 09:00 | 2013-12-13 11:00 | 33 | 0d |  | Consultant1 | 2h |
| 35 | HSDIC.IMP.04.070 | Test Harvest Configuration | 0.62d? | 2013-12-13 11:00 | 2013-12-13 17:00 | 34 | 0d |  | Consultant1 | 5h |
| 36 | HSDIC.IMP.05 | **Clarity Configuration** | 3.38d? | 2013-12-16 08:00 | 2013-12-19 11:00 |  | 0d | as late as possible |  | 27h |
| 37 | HSDIC.IMP.05.010 | Configure Custom Fields for Project Tasks | 0.5d? | 2013-12-16 08:00 | 2013-12-16 12:00 | 35 | 0d |  | Consultant1 | 4h |
| 38 | HSDIC.IMP.05.020 | Provision User IDs | 0.25d? | 2013-12-16 13:00 | 2013-12-16 15:00 | 37 | 0d |  | Consultant1 | 2h |
| 39 | HSDIC.IMP.05.030 | Create Maintenance Projects for Applications | 0.62d? | 2013-12-16 15:00 | 2013-12-17 11:00 | 38 | 0d |  | Consultant1 | 5h |
| 40 | HSDIC.IMP.05.040 | Configure Views | 0.5d? | 2013-12-17 11:00 | 2013-12-17 16:00 | 39 | 0d |  | Consultant1 | 4h |
| 41 | HSDIC.IMP.05.050 | Install Integration Files | 0.5d? | 2013-12-17 16:00 | 2013-12-18 11:00 | 40 | 0d |  | Consultant1 | 4h |
| 42 | HSDIC.IMP.05.060 | Configure Parameter Files | 0.25d? | 2013-12-18 11:00 | 2013-12-18 14:00 | 41 | 0d |  | Consultant1 | 2h |
| 43 | HSDIC.IMP.05.070 | Test Clarity Configuration | 0.5d? | 2013-12-18 14:00 | 2013-12-19 09:00 | 42 | 0d |  | Consultant1 | 4h |
| 44 | HSDIC.IMP.05.080 | Initialize Interface | 0.25d? | 2013-12-19 09:00 | 2013-12-19 11:00 | 43 | 0d |  | Consultant1 | 2h |
| 45 | HSDIC.IMP.06 | **Configuration Review** | 2.5d? | 2013-12-19 11:00 | 2013-12-23 16:00 |  | 0d | as late as possible |  | 20h |
| 46 | HSDIC.IMP.06.010 | Execute System Test Plan | 1d? | 2013-12-19 11:00 | 2013-12-20 11:00 | 44 | 0d |  | Consultant1 | 8h |
| 47 | HSDIC.IMP.06.020 | Conduct Knowledge Transfer Session for Admin | 0.5d? | 2013-12-20 11:00 | 2013-12-20 16:00 | 46 | 0d |  | Consultant1 | 4h |
| 48 | HSDIC.IMP.06.030 | Conduct Knowledge Transfer Session for End Users | 0.5d? | 2013-12-20 16:00 | 2013-12-23 11:00 | 47, 46 | 0d |  | Consultant1 | 4h |
| 49 | HSDIC.IMP.06.040 | Complete Documentation | 0.5d? | 2013-12-23 11:00 | 2013-12-23 16:00 | 48, 46 | 0d |  | Consultant1 | 4h |
| 50 | HSDIC.IMP.07 | **Technical Closure** | 1.12d? | 2013-12-23 16:00 | 2013-12-24 17:00 |  | 0d | as late as possible |  | 9h |
| 51 | HSDIC.IMP.07.010 | Prepare for Final Review | 0.12d? | 2013-12-23 16:00 | 2013-12-23 17:00 | 49 | 0d |  | Consultant1 | 1h |
| 52 | HSDIC.IMP.07.020 | Review Installation with Client Project Sponsor | 0.5d? | 2013-12-24 08:00 | 2013-12-24 12:00 | 51 | 0d |  | Consultant1 | 4h |
| 53 | HSDIC.IMP.07.030 | Conduct Final Review Session | 0.5d? | 2013-12-24 13:00 | 2013-12-24 17:00 | 52 | 0d |  | Consultant1 | 4h |
