# ex_sdic_msp

Schedule from MS Project, 2013-12-03 to 2013-12-24, scheduled back from the finish.
www.bestitdocuments.com

## Calendars

- Standard: Mon-Fri 08:00-12:00, 13:00-17:00; Sat-Sun off.

## Resources

| Resource |
| --- |
| Architect1 |
| Consultant1 |
| Project Manager1 |

## Schedule

| ID | WBS | Task | Duration | Start | Finish | Predecessors | Total slack | Free slack | Constraint | Resources | Work |
| --- | --- | --- | --- | --- | --- | --- | --- | --- | --- | --- | --- |
| 1 | SDIC.IMP | **Integration Set Up** | 15.47d? | 2013-12-03 13:12 | 2013-12-24 17:00 |  | 0d |  | as late as possible |  | 145.8h |
| 2 | SDIC.IMP.01 | **Technical Startup** | 3.29d? | 2013-12-03 13:12 | 2013-12-06 15:30 |  | 0d |  | as late as possible |  | 31.3h |
| 3 | SDIC.IMP.01.010 | Perform Engagement Management Setup Activities | 3.29d? | 2013-12-03 13:12 | 2013-12-06 15:30 |  | 0d |  |  | Project Manager1 | 26.3h |
| 4 | SDIC.IMP.01.020 | Prepare for Engagement | 0.12d? | 2013-12-03 13:12 | 2013-12-03 14:12 |  | 2.66d | 0d |  | Consultant1 | 1h |
| 5 | SDIC.IMP.01.030 | Review Implementation Information with Client | 0.25d? | 2013-12-03 14:12 | 2013-12-03 16:12 | 4 | 2.66d | 0d |  | Consultant1 | 2h |
| 6 | SDIC.IMP.01.040 | Review Project Schedule with Client | 0.25d? | 2013-12-03 16:12 | 2013-12-04 09:12 | 5 | 2.66d |  |  | Consultant1 | 2h |
| 7 | SDIC.IMP.02 | **Architecture and Design** | 2.5d? | 2013-12-06 15:30 | 2013-12-11 10:30 |  | 0d |  | as late as possible |  | 37h |
| 8 | SDIC.IMP.02.010 | Conduct Briefing with Client Project Sponsor | 0.25d? | 2013-12-06 15:30 | 2013-12-09 08:30 | 6, 2 | 0d |  |  | Consultant1 | 2h |
| 9 | SDIC.IMP.02.020 | Conduct Kick-Off Session | 0.12d? | 2013-12-09 08:30 | 2013-12-09 09:30 | 8 | 0d |  |  | Consultant1 | 1h |
| 10 | SDIC.IMP.02.030 | Gather Service Desk Information | 0.12d? | 2013-12-09 09:30 | 2013-12-09 10:30 | 9 | 0d |  |  | Architect1; Consultant1 | 2h |
| 11 | SDIC.IMP.02.040 | Gather Clarity Information | 0.12d? | 2013-12-09 10:30 | 2013-12-09 11:30 | 10 | 0d |  |  | Architect1; Consultant1 | 2h |
| 12 | SDIC.IMP.02.050 | Gather Users and Role Information | 0.12d? | 2013-12-09 11:30 | 2013-12-09 13:30 | 11 | 0d |  |  | Architect1; Consultant1 | 2h |
| 13 | SDIC.IMP.02.060 | Gather Service Desk to Clarity Integration Information | 0.5d? | 2013-12-09 13:30 | 2013-12-10 08:30 | 12 | 0d |  |  | Architect1; Consultant1 | 8h |
| 14 | SDIC.IMP.02.070 | Create Solution Architecture Specification | 1d? | 2013-12-10 08:30 | 2013-12-11 08:30 | 13 | 0d |  |  | Architect1; Consultant1 | 16h |
| 15 | SDIC.IMP.02.080 | Review Solution Architecture Specification with Client | 0.25d? | 2013-12-11 08:30 | 2013-12-11 10:30 | 14 | 0d |  |  | Architect1; Consultant1 | 4h |
| 16 | SDIC.IMP.03 | **Service Desk Configuration** | 2.69d? | 2013-12-11 10:30 | 2013-12-13 17:00 |  | 0d |  | as late as possible |  | 21.5h |
| 17 | SDIC.IMP.03.010 | Install Integration Files | 0.12d? | 2013-12-11 10:30 | 2013-12-11 11:30 | 15 | 0d |  |  | Consultant1 | 1h |
| 18 | SDIC.IMP.03.020 | Configure the Integration Workflow in Service Desk | 0.31d? | 2013-12-11 11:30 | 2013-12-11 15:00 | 17 | 0d |  |  | Consultant1 | 2.5h |
| 19 | SDIC.IMP.03.030 | Configure the Service Desk Forms | 1d? | 2013-12-11 15:00 | 2013-12-12 15:00 | 18 | 0d |  |  | Consultant1 | 8h |
| 20 | SDIC.IMP.03.040 | Create Integration Tables and Populate with Data | 0.5d? | 2013-12-12 15:00 | 2013-12-13 10:00 | 19 | 0d |  |  | Consultant1 | 4h |
| 21 | SDIC.IMP.03.050 | Provision User IDs | 0.25d? | 2013-12-13 10:00 | 2013-12-13 12:00 | 20 | 0d |  |  | Consultant1 | 2h |
| 22 | SDIC.IMP.03.060 | Configure Parameter File for Clarity Integration | 0.25d? | 2013-12-13 13:00 | 2013-12-13 15:00 | 21 | 0d |  |  | Consultant1 | 2h |
| 23 | SDIC.IMP.03.070 | Test Service Desk Configuration | 0.25d? | 2013-12-13 15:00 | 2013-12-13 17:00 | 22 | 0d |  |  | Consultant1 | 2h |
| 24 | SDIC.IMP.04 | **Clarity Configuration** | 3.38d? | 2013-12-16 08:00 | 2013-12-19 11:00 |  | 0d |  | as late as possible |  | 27h |
| 25 | SDIC.IMP.04.010 | Configure Custom Fields for Project Tasks | 0.5d? | 2013-12-16 08:00 | 2013-12-16 12:00 | 23 | 0d |  |  | Consultant1 | 4h |
| 26 | SDIC.IMP.04.020 | Provision User IDs | 0.25d? | 2013-12-16 13:00 | 2013-12-16 15:00 | 25 | 0d |  |  | Consultant1 | 2h |
| 27 | SDIC.IMP.04.030 | Create Maintenance Projects for Applications | 0.62d? | 2013-12-16 15:00 | 2013-12-17 11:00 | 26 | 0d |  |  | Consultant1 | 5h |
| 28 | SDIC.IMP.04.040 | Configure Views | 0.5d? | 2013-12-17 11:00 | 2013-12-17 16:00 | 27 | 0d |  |  | Consultant1 | 4h |
| 29 | SDIC.IMP.04.050 | Install Integration Files | 0.5d? | 2013-12-17 16:00 | 2013-12-18 11:00 | 28 | 0d |  |  | Consultant1 | 4h |
| 30 | SDIC.IMP.04.060 | Configure Parameter Files | 0.25d? | 2013-12-18 11:00 | 2013-12-18 14:00 | 29 | 0d |  |  | Consultant1 | 2h |
| 31 | SDIC.IMP.04.070 | Test Clarity Configuration | 0.5d? | 2013-12-18 14:00 | 2013-12-19 09:00 | 30 | 0d |  |  | Consultant1 | 4h |
| 32 | SDIC.IMP.04.080 | Initialize Interface | 0.25d? | 2013-12-19 09:00 | 2013-12-19 11:00 | 31 | 0d |  |  | Consultant1 | 2h |

| ID | WBS | Task | Duration | Start | Finish | Predecessors | Total slack | Constraint | Resources | Work |
| --- | --- | --- | --- | --- | --- | --- | --- | --- | --- | --- |
| 33 | SDIC.IMP.05 | **Configuration Review** | 2.5d? | 2013-12-19 11:00 | 2013-12-23 16:00 |  | 0d | as late as possible |  | 20h |
| 34 | SDIC.IMP.05.010 | Execute System Test Plan | 1d? | 2013-12-19 11:00 | 2013-12-20 11:00 | 32 | 0d |  | Consultant1 | 8h |
| 35 | SDIC.IMP.05.020 | Conduct Knowledge Transfer Session for Admin | 0.5d? | 2013-12-20 11:00 | 2013-12-20 16:00 | 34 | 0d |  | Consultant1 | 4h |
| 36 | SDIC.IMP.05.030 | Conduct Knowledge Transfer Session for End Users | 0.5d? | 2013-12-20 16:00 | 2013-12-23 11:00 | 35, 34 | 0d |  | Consultant1 | 4h |
| 37 | SDIC.IMP.05.040 | Complete Documentation | 0.5d? | 2013-12-23 11:00 | 2013-12-23 16:00 | 36, 34 | 0d |  | Consultant1 | 4h |
| 38 | SDIC.IMP.06 | **Technical Closure** | 1.12d? | 2013-12-23 16:00 | 2013-12-24 17:00 |  | 0d | as late as possible |  | 9h |
| 39 | SDIC.IMP.06.010 | Prepare for Final Review | 0.12d? | 2013-12-23 16:00 | 2013-12-23 17:00 | 37 | 0d |  | Consultant1 | 1h |
| 40 | SDIC.IMP.06.020 | Review Installation with Client Project Sponsor | 0.5d? | 2013-12-24 08:00 | 2013-12-24 12:00 | 39 | 0d |  | Consultant1 | 4h |
| 41 | SDIC.IMP.06.030 | Conduct Final Review Session | 0.5d? | 2013-12-24 13:00 | 2013-12-24 17:00 | 40 | 0d |  | Consultant1 | 4h |
