# Enterprise Change Management Process

Schedule from MS Project, 2012-07-12 to 2012-07-20, scheduled back from the finish.
www.bestitdocuments.com

## Calendars

- Standard: Mon-Fri 08:00-12:00, 13:00-17:00; Sat-Sun off.

## Resources

| Resource |
| --- |
| Engagement Leader1 |
| Principal Consultant1 |
| Senior Consultant1 |

## Schedule

| ID | WBS | Task | Duration | Start | Finish | Predecessors | Total slack | Constraint | Resources | Work |
| --- | --- | --- | --- | --- | --- | --- | --- | --- | --- | --- |
| 1 | CMAR.CMA | **CM Risk Assessment** | 6.62d? | 2012-07-12 11:00 | 2012-07-20 17:00 |  | 0d | as late as possible |  | 108h |
| 2 | CMAR.CMA.01 | **Technical Startup** | 0.5d? | 2012-07-12 11:00 | 2012-07-12 16:00 |  | 0d | as late as possible |  | 10h |
| 3 | CMAR.CMA.01.010 | Perform Engagement Management Setup Activities | 0.25d? | 2012-07-12 11:00 | 2012-07-12 14:00 |  | 6.38d |  | Engagement Leader1 | 2h |
| 4 | CMAR.CMA.01.020 | Prepare for Engagement | 0.12d? | 2012-07-12 11:00 | 2012-07-12 12:00 |  | 0d |  | Principal Consultant1; Senior Consultant1 | 2h |
| 5 | CMAR.CMA.01.030 | Conduct Initial Briefing Session with Client Project Sponsor | 0.12d? | 2012-07-12 13:00 | 2012-07-12 14:00 | 4 | 0d |  | Principal Consultant1; Senior Consultant1 | 2h |
| 6 | CMAR.CMA.01.040 | Identify Client Goals | 0.12d? | 2012-07-12 14:00 | 2012-07-12 15:00 | 5 | 0d |  | Principal Consultant1; Senior Consultant1 | 2h |
| 7 | CMAR.CMA.01.050 | Conduct Kick-Off Session | 0.12d? | 2012-07-12 15:00 | 2012-07-12 16:00 | 6 | 0d |  | Principal Consultant1; Senior Consultant1 | 2h |
| 8 | CMAR.CMA.02 | **Change Management Process Review** | 3.62d? | 2012-07-12 16:00 | 2012-07-18 12:00 |  | 0d | as late as possible |  | 58h |
| 9 | CMAR.CMA.02.010 | Review Client CM Information | 0.5d? | 2012-07-12 16:00 | 2012-07-13 11:00 | 7 | 0d |  | Principal Consultant1; Senior Consultant1 | 8h |
| 10 | CMAR.CMA.02.020 | Finalize Interview Questionnaire | 0.12d? | 2012-07-13 11:00 | 2012-07-13 12:00 | 9 | 0d |  | Principal Consultant1; Senior Consultant1 | 2h |
| 11 | CMAR.CMA.02.030 | Confirm Availability of Individuals to be Interviewed | 0.12d? | 2012-07-13 13:00 | 2012-07-13 14:00 | 10 | 0d |  | Principal Consultant1; Senior Consultant1 | 2h |
| 12 | CMAR.CMA.02.040 | Schedule Interviews | 0.12d? | 2012-07-13 14:00 | 2012-07-13 15:00 | 11 | 0d |  | Principal Consultant1; Senior Consultant1 | 2h |
| 13 | CMAR.CMA.02.050 | Conduct Interviews | 1.5d? | 2012-07-13 15:00 | 2012-07-17 10:00 | 12 | 0d |  | Principal Consultant1; Senior Consultant1 | 24h |
| 14 | CMAR.CMA.02.060 | Consolidate Interview Results | 0.5d? | 2012-07-17 10:00 | 2012-07-17 15:00 | 13 | 0d |  | Principal Consultant1; Senior Consultant1 | 8h |
| 15 | CMAR.CMA.02.070 | Schedule Individual Sessions with Key Client Personnel | 0.5d? | 2012-07-17 15:00 | 2012-07-18 10:00 | 14 | 0d |  | Principal Consultant1; Senior Consultant1 | 8h |
| 16 | CMAR.CMA.02.080 | Resolve Issues | 0.12d? | 2012-07-18 10:00 | 2012-07-18 11:00 | 15 | 0d |  | Principal Consultant1; Senior Consultant1 | 2h |
| 17 | CMAR.CMA.02.090 | Review Information with Client Project Sponsor | 0.12d? | 2012-07-18 11:00 | 2012-07-18 12:00 | 16 | 0d |  | Principal Consultant1; Senior Consultant1 | 2h |
| 18 | CMAR.CMA.03 | **Change Management Recommendations Definition** | 0.62d? | 2012-07-18 13:00 | 2012-07-19 09:00 |  | 0d | as late as possible |  | 10h |
| 19 | CMAR.CMA.03.010 | Observe CM Processes | 0.25d? | 2012-07-18 13:00 | 2012-07-18 15:00 | 17 | 0d |  | Principal Consultant1; Senior Consultant1 | 4h |
| 20 | CMAR.CMA.03.020 | Identify CM Gaps and Opportunities | 0.12d? | 2012-07-18 15:00 | 2012-07-18 16:00 | 19 | 0d |  | Principal Consultant1; Senior Consultant1 | 2h |
| 21 | CMAR.CMA.03.030 | Conduct Risk Analysis | 0.25d? | 2012-07-18 16:00 | 2012-07-19 09:00 | 20 | 0d |  | Principal Consultant1; Senior Consultant1 | 4h |
| 22 | CMAR.CMA.04 | **Technical Closure** | 1.88d? | 2012-07-19 09:00 | 2012-07-20 17:00 |  | 0d | as late as possible |  | 30h |
| 23 | CMAR.CMA.04.010 | Produce Initial CM Risk Assessment Presentation | 1d? | 2012-07-19 09:00 | 2012-07-20 09:00 | 21 | 0d |  | Principal Consultant1; Senior Consultant1 | 16h |
| 24 | CMAR.CMA.04.020 | Review Preliminary Results with Client Project Sponsor | 0.5d? | 2012-07-20 09:00 | 2012-07-20 14:00 | 23 | 0d |  | Principal Consultant1; Senior Consultant1 | 8h |
| 25 | CMAR.CMA.04.030 | Produce Final CM Risk Assessment Presentation | 0.25d? | 2012-07-20 14:00 | 2012-07-20 16:00 | 24 | 0d |  | Principal Consultant1; Senior Consultant1 | 4h |
| 26 | CMAR.CMA.04.040 | Present Results to Client | 0.12d? | 2012-07-20 16:00 | 2012-07-20 17:00 | 25 | 0d |  | Principal Consultant1; Senior Consultant1 | 2h |
