# SDLC_PBR

Schedule from MS Project, 2013-12-20 to 2014-03-28, scheduled back from the finish.
www.bestitdocuments.com

## Calendars

- Standard: Mon-Fri 08:00-12:00, 13:00-17:00; Sat-Sun off.

## Schedule

| ID | WBS | Task | Duration | Start | Finish | Predecessors | Total slack | Free slack | Constraint |
| --- | --- | --- | --- | --- | --- | --- | --- | --- | --- |
| 1 | 1 | **Conversion Schedule with deliverables** | 71d | 2013-12-20 | 2014-03-28 |  | 0d |  | as late as possible |
| 2 | 1.1 | **Assessment** | 71d | 2013-12-20 | 2014-03-28 |  | 0d |  | as late as possible |
| 3 | 1.1.1 | Prepare Schedule | 20d | 2013-12-20 | 2014-01-16 |  | 48d | 0d |  |
| 4 | 1.1.2 | Prepare Project Budget | 5d | 2013-12-20 | 2013-12-26 |  | 65d | 0d |  |
| 5 | 1.1.3 | Prepare High Level Inventory | 10d | 2013-12-20 | 2014-01-02 |  | 60d | 0d |  |
| 6 | 1.1.4 | Prepare Environment Analysis | 8d | 2013-12-20 | 2013-12-31 |  | 56d | 0d |  |
| 7 | 1.1.5 | Prepare Retrofit Plan | 24d | 2013-12-20 | 2014-01-22 |  | 46d | 0d |  |
| 8 | 1.1.6 | Prepare Project Plan | 26d | 2013-12-20 | 2014-01-24 |  | 44d | 0d |  |
| 9 | 1.1.7 | **Due Diligence Deliverables** | 27d | 2013-12-20 | 2014-01-27 |  | 0d |  | as late as possible |
| 10 | 1.1.7.1 | Submit Vendor SOW | 1d | 2013-12-20 | 2013-12-20 |  | 70d |  |  |
| 11 | 1.1.7.2 | Submit Project Budget | 1d | 2013-12-27 | 2013-12-27 | 4 | 65d |  |  |
| 12 | 1.1.7.3 | Submit High Level Inventory | 1d | 2014-01-03 | 2014-01-03 | 5 | 60d |  |  |
| 13 | 1.1.7.4 | Submit Assesment Schedule | 1d | 2014-01-17 | 2014-01-17 | 3 | 48d | 0d |  |
| 14 | 1.1.7.5 | Submit Environment Analysis | 1d | 2014-01-01 | 2014-01-01 | 6 | 56d | 0d |  |
| 15 | 1.1.7.6 | Submit Retrofit Plan | 1d | 2014-01-23 | 2014-01-23 | 7 | 46d |  |  |
| 16 | 1.1.7.7 | Submit Project Plan | 1d | 2014-01-27 | 2014-01-27 | 8 | 44d |  |  |
| 17 | 1.1.8 | **Analysis** | 60d | 2013-12-20 | 2014-03-13 |  | 0d |  | as late as possible |
| 18 | 1.1.8.1 | Update Schedule | 1d | 2014-01-20 | 2014-01-20 | 13 | 48d | 0d |  |
| 19 | 1.1.8.2 | Update Environment Analysis | 5d | 2014-01-02 | 2014-01-08 | 14 | 56d | 0d |  |
| 20 | 1.1.8.3 | **Detailed Date Analysis** | 8d | 2013-12-20 | 2013-12-31 |  | 0d |  | as late as possible |
| 21 | 1.1.8.3.1 | Prepare Detailed Date Analysis | 8d | 2013-12-20 | 2013-12-31 |  | 62d | 0d |  |
| 22 | 1.1.8.4 | Update Retrofit Plan | 1d | 2013-12-20 | 2013-12-20 |  | 59d | 0d |  |
| 23 | 1.1.8.5 | **Project Plan** | 12d | 2013-12-20 | 2014-01-06 |  | 0d |  | as late as possible |
| 24 | 1.1.8.5.1 | Update Project Plan | 5d | 2013-12-20 | 2013-12-26 |  | 41d | 0d |  |
| 25 | 1.1.8.5.2 | Review by App Mgr | 2d | 2013-12-27 | 2013-12-30 | 24 | 41d | 0d |  |
| 26 | 1.1.8.5.3 | Incorporate Revisions/Update | 5d | 2013-12-31 | 2014-01-06 | 25 | 41d | 0d |  |

| ID | WBS | Task | Duration | Start | Finish | Predecessors | Total slack | Free slack | Constraint |
| --- | --- | --- | --- | --- | --- | --- | --- | --- | --- |
| 27 | 1.1.8.6 | **Master Test Plan** | 59d | 2013-12-20 | 2014-03-12 |  | 0d |  | as late as possible |
| 28 | 1.1.8.6.1 | Prepare Master Test Plan | 59d | 2013-12-20 | 2014-03-12 |  | 0d |  |  |
| 29 | 1.1.8.7 | **Due Diligence Deliverables** | 59d | 2013-12-23 | 2014-03-13 |  | 0d |  | as late as possible |
| 30 | 1.1.8.7.1 | Submit Schedule | 1d | 2014-01-21 | 2014-01-21 | 18 | 48d |  |  |
| 31 | 1.1.8.7.2 | Submit Environment Analysis | 1d | 2014-01-09 | 2014-01-09 | 19 | 56d |  |  |
| 32 | 1.1.8.7.3 | Submit Retrofit Plan | 1d | 2013-12-23 | 2013-12-23 | 22 | 59d | 0d |  |
| 33 | 1.1.8.7.4 | Submit Project Plan | 1d | 2014-01-07 | 2014-01-07 | 26 | 41d | 0d |  |
| 34 | 1.1.8.7.5 | Submit Detailed Date Analysis | 1d | 2014-01-01 | 2014-01-01 | 21 | 62d |  |  |
| 35 | 1.1.8.7.6 | Submit Master Test Plan | 1d | 2014-03-13 | 2014-03-13 | 28 | 0d |  |  |
| 36 | 1.1.9 | **Detailed Design** | 71d | 2013-12-20 | 2014-03-28 |  | 0d |  | as late as possible |
| 37 | 1.1.9.1 | **Schedule** | 1d | 2013-12-20 | 2013-12-20 |  | 0d |  | as late as possible |
| 38 | 1.1.9.1.1 | Update Schedule | 1d | 2013-12-20 | 2013-12-20 |  | 58d | 0d |  |
| 39 | 1.1.9.2 | Update Retrofit Plan | 5d | 2013-12-24 | 2013-12-30 | 32 | 59d | 0d |  |
| 40 | 1.1.9.3 | **Project Plan** | 10d | 2014-01-08 | 2014-01-21 |  | 0d |  | as late as possible |
| 41 | 1.1.9.3.1 | Update Project Plan | 5d | 2014-01-08 | 2014-01-14 | 33 | 41d | 0d |  |
| 42 | 1.1.9.3.2 | Review by App Mgr | 2d | 2014-01-15 | 2014-01-16 | 41 | 41d | 0d |  |
| 43 | 1.1.9.3.3 | Incorporate Revisions/Update | 3d | 2014-01-17 | 2014-01-21 | 42 | 41d | 0d |  |
| 44 | 1.1.9.4 | **Master Test Plan** | 10d | 2014-03-14 | 2014-03-27 |  | 0d |  | as late as possible |
| 45 | 1.1.9.4.1 | Develop Test Scripts | 10d | 2014-03-14 | 2014-03-27 | 35 | 0d |  |  |
| 46 | 1.1.9.5 | **Due Diligence Deliverables** | 70d | 2013-12-23 | 2014-03-28 |  | 0d |  | as late as possible |
| 47 | 1.1.9.5.1 | Submit Updated Schedule | 1d | 2013-12-23 | 2013-12-23 | 38 | 58d | 0d |  |
| 48 | 1.1.9.5.2 | Submit Updated Retrofit Plan | 1d | 2013-12-31 | 2013-12-31 | 39 | 59d | 0d |  |
| 49 | 1.1.9.5.3 | Submit Project Plan | 1d | 2014-01-22 | 2014-01-22 | 43 | 41d | 0d |  |
| 50 | 1.1.9.5.4 | Submit updated Master Test Plan | 1d | 2014-03-28 | 2014-03-28 | 45 | 0d |  |  |

| ID | WBS | Task | Duration | Start | Finish | Predecessors | Total slack | Free slack | Constraint |
| --- | --- | --- | --- | --- | --- | --- | --- | --- | --- |
| 51 | 1.1.10 | **Conversion** | 39d | 2013-12-20 | 2014-02-12 |  | 0d |  | as late as possible |
| 52 | 1.1.10.1 | Update Schedule | 10d | 2013-12-24 | 2014-01-06 | 47 | 58d | 0d |  |
| 53 | 1.1.10.2 | Submit Schedule | 1d | 2014-01-07 | 2014-01-07 | 52 | 58d |  |  |
| 54 | 1.1.10.3 | Pre-remediation Test | 10d | 2013-12-20 | 2014-01-02 |  | 24d | 0d |  |
| 55 | 1.1.10.4 | Update Retrofit Plan | 3d | 2014-01-01 | 2014-01-03 | 48 | 59d | 0d |  |
| 56 | 1.1.10.5 | Submit Retrofit Plan | 1d | 2014-01-06 | 2014-01-06 | 55 | 59d |  |  |
| 57 | 1.1.10.6 | Update Project Plan | 5d | 2014-01-23 | 2014-01-29 | 49 | 41d | 0d |  |
| 58 | 1.1.10.7 | Submit Project Plan | 1d | 2014-01-30 | 2014-01-30 | 57 | 41d |  |  |
| 59 | 1.1.10.8 | Post-remediation Test | 10d | 2014-01-03 | 2014-01-16 | 54 | 24d | 0d |  |
| 60 | 1.1.10.9 | App Testing | 10d | 2014-01-17 | 2014-01-30 | 59 | 24d | 0d |  |
| 61 | 1.1.10.10 | **Final Inspection Report** | 9d | 2014-01-31 | 2014-02-12 |  | 0d |  | as late as possible |
| 62 | 1.1.10.10.1 | Prepare Inspection Report Plan | 5d | 2014-01-31 | 2014-02-06 | 60 | 24d | 0d |  |
| 63 | 1.1.10.10.2 | Submit Inspection Report Plan | 1d | 2014-02-07 | 2014-02-07 | 62 | 35d |  |  |
| 64 | 1.1.10.10.3 | Update Master Test Plan with Results | 8d | 2014-01-31 | 2014-02-11 | 60 | 28d | 0d |  |
| 65 | 1.1.10.10.4 | Submit Master Test Plan with Results | 1d | 2014-02-12 | 2014-02-12 | 64 | 32d |  |  |
| 66 | 1.1.11 | **Implementation** | 47d | 2013-12-20 | 2014-02-24 |  | 0d |  | as late as possible |
| 67 | 1.1.11.1 | **Installation Report** | 12d | 2014-02-07 | 2014-02-24 |  | 0d |  | as late as possible |
| 68 | 1.1.11.1.1 | Prepare Installation Report | 5d | 2014-02-07 | 2014-02-13 | 62 | 24d | 0d |  |
| 69 | 1.1.11.1.2 | Submit Installation Report | 1d | 2014-02-14 | 2014-02-14 | 68 | 24d | 0d |  |
| 70 | 1.1.11.1.3 | Prepare Platform Compliance Form | 5d | 2014-02-17 | 2014-02-21 | 69 | 24d | 0d |  |
| 71 | 1.1.11.1.4 | Submit Platform Compliance Form | 1d | 2014-02-24 | 2014-02-24 | 70 | 24d |  |  |
| 72 | 1.1.11.2 | **Project Wrapup Report** | 43d | 2013-12-20 | 2014-02-18 |  | 0d |  | as late as possible |
| 73 | 1.1.11.2.1 | Prepare Project Wrapup Report | 3d | 2013-12-20 | 2013-12-24 |  | 67d | 0d |  |
| 74 | 1.1.11.2.2 | Submit Project Wrapup Report | 1d | 2013-12-25 | 2013-12-25 | 73 | 67d |  |  |
| 75 | 1.1.11.2.3 | Final Review | 5d | 2014-02-12 | 2014-02-18 | 64 | 28d |  |  |
| 76 | 1.1.11.2.4 | Application Platform Compliance Signoff submittal | 1d | 2013-12-20 | 2013-12-20 |  | 70d |  |  |
| 77 | 1.1.11.2.5 | Project Implementation | 5d | 2014-01-31 | 2014-02-06 | 60 | 31d | 0d |  |

| ID | WBS | Task | Duration | Start | Finish | Predecessors | Total slack | Constraint |
| --- | --- | --- | --- | --- | --- | --- | --- | --- |
| 78 | 1.1.12 | **QA Submittal** | 5d | 2014-02-07 | 2014-02-13 |  | 0d | as late as possible |
| 79 | 1.1.12.1 | Submit All Final Docs to PMO | 5d | 2014-02-07 | 2014-02-13 | 77 | 31d |  |
